# CSF Upgrades and Migrations

Schedule from MS Project, 2013-01-14 to 2013-05-28, A marks actual dates.
MIT

## Calendars

- Standard: Mon-Fri 08:00-12:00, 13:00-17:00; Sat-Sun off.

## Resources

| Resource |
| --- |
| Dave |
| René |
| Steve |
| Felicia |
| Ram |
| Kevin |
| Brian |
| Janet |
| Seth |
| Lee |
| Faith |
| Peter |
| Debra |

## Schedule

| ID | WBS | Task | Type | Duration | Start | Finish | Predecessors | Complete | Remaining | Baseline start | Baseline finish | Baseline duration | Total slack | Free slack | Resources | Work | Actual work |
| --- | --- | --- | --- | --- | --- | --- | --- | --- | --- | --- | --- | --- | --- | --- | --- | --- | --- |
| 1 | 1 | Upgrade CSF to 2.0 |  | 10d | 2013-01-14 A | 2013-01-25 A |  | 100% |  |  |  |  |  |  |  |  |  |
| 2 | 2 | **Upgrade of Existing CSF Apps to CSF 2.0** |  | 40d? | 2013-01-14 A | 2013-03-08 |  | 10% | 36.19d? | 2013-02-13 | 2013-03-08 | 18d? | 56d |  |  | 141.6h | 16h |
| 3 | 2.1 | **Development** |  | 18d | 2013-02-13 A | 2013-03-08 |  | 20% | 14.4d | 2013-02-13 | 2013-03-08 | 18d | 56d |  |  | 80h | 16h |
| 4 | 2.1.1 | Upgrade IAP |  | 4d | 2013-02-14 | 2013-02-20 | 1FS+13d |  |  | 2013-02-14 | 2013-02-20 | 4d | 60d | 0d | Steve [50%] | 16h |  |
| 5 | 2.1.2 | Upgrade Subject Evaluation |  | 4d | 2013-02-26 | 2013-03-01 | 4FS+3d |  |  | 2013-02-26 | 2013-03-01 | 4d | 60d | 5d | Steve [50%] | 16h |  |
| 6 | 2.1.3 | Upgrade Sponsor Billing |  | 4d | 2013-02-13 A | 2013-02-19 A | 1FS+12d | 100% |  | 2013-02-13 | 2013-02-19 | 4d |  |  | Dave [50%] | 16h | 16h |
| 7 | 2.1.4 | Upgrade Survey Engine |  | 4d | 2013-02-26 | 2013-03-01 | 6FS+4d |  |  | 2013-02-26 | 2013-03-01 | 4d | 55d | 0d | Dave [50%] | 16h |  |
| 8 | 2.1.5 | Upgrade Subject Evaluation Report |  | 4d | 2013-03-05 | 2013-03-08 | 7FS+1d |  |  | 2013-03-05 | 2013-03-08 | 4d | 55d | 0d | Dave [50%] | 16h |  |
| 9 | 2.1.6 | Upgrades complete | milestone | 0d | 2013-03-08 | 2013-03-08 | 4, 5, 6, 7, 8 |  |  | 2013-03-08 | 2013-03-08 | 0d | 56d |  | Dave [50%]; Steve [50%] |  |  |
| 10 | 2.2 | **Testing** |  | 39d? | 2013-01-14 | 2013-03-07 |  |  |  |  |  |  | 57d |  |  | 37.6h |  |
| 11 | 2.2.1 | **Test Planning** |  | 4d? | 2013-02-20 | 2013-02-25 |  |  |  |  |  |  | 56d |  |  | 15.6h |  |
| 12 | 2.2.1.1 | IAP and Sponsor Billing |  | 3d | 2013-02-20 | 2013-02-22 | 4SS+4d |  |  |  |  |  | 62d | 0d | Seth [25%]; Faith [25%] | 7.6h |  |
| 13 | 2.2.1.2 | OFS Applications |  | 1d? | 2013-02-25 | 2013-02-25 | 12 |  |  |  |  |  | 63d | 0d | Lee | 8h |  |
| 14 | 2.2.1.3 | Test Planning Complete | milestone | 0d | 2013-02-25 | 2013-02-25 | 12, 13 |  |  |  |  |  | 64d | 2d |  |  |  |
| 15 | 2.2.2 | **BA Testing** |  | 9d? | 2013-02-25 | 2013-03-07 |  |  |  |  |  |  | 56d |  |  | 22h |  |
| 16 | 2.2.2.1 | Sponsor Billing |  | 3d | 2013-02-25 | 2013-02-27 | 12 |  |  |  |  |  | 56d | 0d | Faith [25%] | 6h |  |
| 17 | 2.2.2.2 | IAP |  | 4d | 2013-03-04 | 2013-03-07 | 16FS+2d |  |  |  |  |  | 56d |  | Seth [25%] | 8h |  |
| 18 | 2.2.2.3 | OFS Applications |  | 1d? | 2013-02-26 | 2013-02-26 | 13 |  |  |  |  |  | 63d | 1d | Lee | 8h |  |
| 19 | 2.2.2.4 | BA Testing Complete | milestone | 0d | 2013-02-27 | 2013-02-27 | 16, 18 |  |  |  |  |  | 62d | 0d |  |  |  |
| 20 | 2.2.3 | **UAT** |  | 1d? | 2013-01-14 | 2013-01-14 |  |  |  |  |  |  | 94d |  |  |  |  |
| 21 | 2.2.3.1 | IAP |  | 1d? | 2013-01-14 | 2013-01-14 |  |  |  |  |  |  | 94d | 0d |  |  |  |
| 22 | 2.2.3.2 | Subject Evaluation |  | 1d? | 2013-01-14 | 2013-01-14 |  |  |  |  |  |  | 94d | 0d |  |  |  |
| 23 | 2.2.3.3 | Sponsor Billing |  | 1d? | 2013-01-14 | 2013-01-14 |  |  |  |  |  |  | 94d | 0d |  |  |  |
| 24 | 2.2.3.4 | Survey Engine |  | 1d? | 2013-01-14 | 2013-01-14 |  |  |  |  |  |  | 94d | 0d |  |  |  |
| 25 | 2.2.3.5 | Subject Evaluation Report |  | 1d? | 2013-01-14 | 2013-01-14 |  |  |  |  |  |  | 94d | 0d |  |  |  |
| 26 | 2.2.3.6 | UAT Complete | milestone | 0d | 2013-01-14 | 2013-01-14 | 21, 22, 23, 24, 25 |  |  |  |  |  | 94d | 32d |  |  |  |
| 27 | 2.2.4 | Testing Efforts Complete |  | 1d? | 2013-02-28 | 2013-02-28 | 14, 19, 26 |  |  |  |  |  | 62d |  |  |  |  |

| ID | WBS | Task | Type | Duration | Start | Finish | Predecessors | Complete | Remaining | Baseline start | Baseline finish | Baseline duration | Total slack | Free slack | Resources | Work | Actual work |
| --- | --- | --- | --- | --- | --- | --- | --- | --- | --- | --- | --- | --- | --- | --- | --- | --- | --- |
| 28 | 2.3 | **Deployment Preparation** |  | 1d? | 2013-01-14 | 2013-01-14 |  |  |  |  |  |  | 94d |  |  | 24h |  |
| 29 | 2.3.1 | Create deployment plan |  | 1d? | 2013-01-14 | 2013-01-14 |  |  |  |  |  |  | 94d |  | René | 8h |  |
| 30 | 2.3.2 | Review deployment plan with participants |  | 1d? | 2013-01-14 | 2013-01-14 |  |  |  |  |  |  | 94d |  | René | 8h |  |
| 31 | 2.3.3 | Create registration support plan |  | 1d? | 2013-01-14 | 2013-01-14 |  |  |  |  |  |  | 94d |  | René | 8h |  |
| 32 | 2.4 | **Go-live** |  | 1d? | 2013-01-14 | 2013-01-14 |  |  |  |  |  |  | 95d |  |  |  |  |
| 33 | 2.4.1 | Prod smoke test |  | 1d? | 2013-01-14 | 2013-01-14 |  |  |  |  |  |  | 95d | 0d |  |  |  |
| 34 | 2.5 | Upgrade of Existing CSF Apps to CSF 2.0 Complete | milestone | 0d | 2013-01-14 | 2013-01-14 | 33 |  |  |  |  |  | 95d |  |  |  |  |
| 35 | 3 | **Convert SAIS-Common Apps to CSF 2.0** |  | 1d? | 2013-01-14 | 2013-01-14 |  |  |  |  |  |  | 95d |  |  |  |  |
| 36 | 3.1 | Development |  | 1d? | 2013-01-14 | 2013-01-14 |  |  |  |  |  |  | 95d |  |  |  |  |
| 37 | 3.2 | Testing |  | 1d? | 2013-01-14 | 2013-01-14 |  |  |  |  |  |  | 95d |  |  |  |  |
| 38 | 4 | **PE REG Upgrade** |  | 57d? | 2013-01-14 A | 2013-04-02 |  | 9% | 51.72d? | 2013-02-07 | 2013-03-07 | 21d? | 39d |  |  | 272h | 40h |
| 39 | 4.1 | **Phase I - Java 6, Touchstone, and CSF Enabling** |  | 39d? | 2013-02-07 A | 2013-04-02 |  | 10% | 35.02d? | 2013-02-07 | 2013-03-07 | 21d? | 39d |  |  | 256h | 40h |
| 40 | 4.1.1 | **Development** |  | 27d | 2013-02-07 A | 2013-03-15 |  | 19% | 21.81d | 2013-02-07 | 2013-03-07 | 21d | 39d |  |  | 208h | 40h |
| 41 | 4.1.1.1 | Do set-up and configuration required for upgrade |  | 5d | 2013-02-07 A | 2013-02-13 A |  | 100% |  | 2013-02-07 | 2013-02-13 | 5d |  |  | Ram | 40h | 40h |
| 42 | 4.1.1.2 | Perform upgrade |  | 7d | 2013-02-14 A | 2013-02-25 | 41 |  | 7d | 2013-02-14 | 2013-02-21 | 5d | 39d | 0d | Ram | 56h |  |
| 43 | 4.1.1.3 | Unit test changes |  | 14d | 2013-02-26 | 2013-03-15 | 42 |  |  | 2013-02-22 | 2013-03-07 | 10d | 39d | 0d | Ram | 112h |  |
| 44 | 4.1.2 | **Testing** |  | 29d? | 2013-02-20 | 2013-04-01 |  |  |  |  |  |  | 39d |  |  | 48h |  |
| 45 | 4.1.2.1 | Test planning |  | 12d | 2013-02-20 | 2013-03-07 | 42SS+4d |  |  |  |  |  | 45d | 6d | Debra [25%] | 24h |  |
| 46 | 4.1.2.2 | QA testing |  | 5d | 2013-03-18 | 2013-03-22 | 45, 43 |  |  |  |  |  | 39d | 0d | Debra [25%] | 10h |  |
| 47 | 4.1.2.3 | QA bug fix testing |  | 3d | 2013-03-25 | 2013-03-27 | 46 |  |  |  |  |  | 39d | 0d | Debra [25%] | 6h |  |
| 48 | 4.1.2.4 | Load testing |  | 1d? | 2013-03-28 | 2013-03-28 | 47 |  |  |  |  |  | 41d |  | Ram | 8h |  |
| 49 | 4.1.2.5 | User testing |  | 1d? | 2013-04-01 | 2013-04-01 | 47FS+2d |  |  |  |  |  | 39d | 0d |  |  |  |
| 50 | 4.1.3 | Go-live |  | 1d? | 2013-04-02 | 2013-04-02 | 49 |  |  |  |  |  | 39d | 0d |  |  |  |
| 51 | 4.2 | **Phase II - Full CSF Upgrade** |  | 47d? | 2013-01-14 | 2013-03-19 |  |  |  |  |  |  | 49d |  |  | 16h |  |
| 52 | 4.2.1 | **Development** |  | 2d? | 2013-03-18 | 2013-03-19 |  |  |  |  |  |  | 48d |  |  | 16h |  |
| 53 | 4.2.1.1 | Perform full upgrade |  | 1d? | 2013-03-18 | 2013-03-18 | 43 |  |  |  |  |  | 48d | 0d | Ram | 8h |  |
| 54 | 4.2.1.2 | Unit test changes |  | 1d? | 2013-03-19 | 2013-03-19 | 53 |  |  |  |  |  | 48d |  | Ram | 8h |  |

| ID | WBS | Task | Type | Duration | Start | Finish | Predecessors | Baseline start | Baseline finish | Baseline duration | Total slack | Free slack | Constraint | Resources | Work |
| --- | --- | --- | --- | --- | --- | --- | --- | --- | --- | --- | --- | --- | --- | --- | --- |
| 55 | 4.2.2 | **Testing** |  | 1d? | 2013-01-14 | 2013-01-14 |  |  |  |  | 95d |  |  |  |  |
| 56 | 4.2.2.1 | QA |  | 1d? | 2013-01-14 | 2013-01-14 |  |  |  |  | 95d |  |  |  |  |
| 57 | 4.2.2.2 | User |  | 1d? | 2013-01-14 | 2013-01-14 |  |  |  |  | 95d |  |  |  |  |
| 58 | 4.2.3 | Go-live |  | 1d? | 2013-01-14 | 2013-01-14 |  |  |  |  | 95d | 56d |  |  |  |
| 59 | 4.3 | PE REG upgrade complete | milestone | 0d | 2013-04-02 | 2013-04-02 | 50, 58 |  |  |  | 39d |  |  | Ram |  |
| 60 | 5 | **Convert OREG to CSF 2.0** |  | 76d | 2013-02-11 | 2013-05-28 |  | 2013-02-11 | 2013-05-28 | 76d | 0d |  |  |  | 624h |
| 61 | 5.1 | **Development (including unit testing)** |  | 35d | 2013-02-11 | 2013-03-29 |  | 2013-02-11 | 2013-03-22 | 29d | 0d |  |  |  | 272h |
| 62 | 5.1.1 | Phase 1 - Required as-is , high priority (A/D and OREG) |  | 9d | 2013-02-11 | 2013-02-22 |  |  |  |  | 0d |  | start no earlier than 2013-02-11 | Felicia | 72h |
| 63 | 5.1.2 | Phase 2 - Medium priority validation and messaging |  | 15d | 2013-02-25 | 2013-03-15 | 62 |  |  |  | 0d |  |  | Felicia | 120h |
| 64 | 5.1.3 | Phase 3 - Stabilize JAR and rafactor CSF dependencies |  | 5d | 2013-03-18 | 2013-03-22 | 63 |  |  |  | 0d |  |  | Felicia | 40h |
| 65 | 5.1.4 | Phase 4 - Modify OREG to use new JAR and upgrade to CSF 2.0 |  | 5d | 2013-03-25 | 2013-03-29 | 64 |  |  |  | 0d |  |  | Felicia | 40h |
| 66 | 5.1.5 | Development complete | milestone | 0d | 2013-03-29 | 2013-03-29 | 65 |  |  |  | 0d |  |  | Felicia |  |
| 67 | 5.2 | Regression Testing |  | 24d | 2013-04-01 | 2013-05-03 | 66 | 2013-03-25 | 2013-04-26 | 24d | 0d |  |  | Kevin | 192h |
| 68 | 5.3 | UAT |  | 20d | 2013-04-29 | 2013-05-24 | 67FS-5d | 2013-04-29 | 2013-05-24 | 20d | 0d |  |  | Brian | 160h |
| 69 | 5.4 | Go-live | milestone | 0d | 2013-05-28 | 2013-05-28 |  | 2013-05-28 | 2013-05-28 | 0d | 0d |  | start no earlier than 2013-05-28 | René |  |
| 70 | 6 | **Notes Utility Beta** |  | 96d? | 2013-01-14 | 2013-05-28 |  |  |  |  | 0d |  |  |  | 8h |
| 71 | 6.1 | Development |  | 1d? | 2013-04-01 | 2013-04-01 | 61 |  |  |  | 39d |  |  | Felicia | 8h |
| 72 | 6.2 | UAT |  | 1d? | 2013-01-14 | 2013-01-14 |  |  |  |  | 95d |  |  |  |  |
| 73 | 6.3 | Go-live | milestone | 0d | 2013-05-28 | 2013-05-28 |  |  |  |  | 0d |  | start no earlier than 2013-05-28 | René |  |
| 75 | 6.4 | Requirements |  | 1d? | 2013-01-14 | 2013-01-14 |  |  |  |  | 95d |  |  |  |  |
| 76 | 6.5 | Functional Specification |  | 1d? | 2013-01-14 | 2013-01-14 |  |  |  |  | 95d |  |  |  |  |
| 77 | 6.6 | **Technical Analysis and Design - Spring Messages** |  | 3d | 2013-01-14 | 2013-01-16 |  |  |  |  | 93d |  |  |  |  |
| 78 | 6.6.1 | Write Technical Specification |  | 3d | 2013-01-14 | 2013-01-16 |  |  |  |  | 93d |  |  |  |  |
| 79 | 6.6.2 | Review Technical Specification with Technical Team | milestone | 0d | 2013-01-14 | 2013-01-14 |  |  |  |  | 96d |  |  |  |  |
| 80 | 6.6.3 | Update Specification based on feedback |  | 2d | 2013-01-14 | 2013-01-15 |  |  |  |  | 94d |  |  |  |  |
| 81 | 6.6.4 | Technical Analysis and Design Complete | milestone | 0d | 2013-01-14 | 2013-01-14 |  |  |  |  | 96d |  |  |  |  |

| ID | WBS | Task | Type | Duration | Start | Finish | Total slack |
| --- | --- | --- | --- | --- | --- | --- | --- |
| 82 | 6.7 | **Technical Analysis and Design - Rules Engine/OREG Decoupling** |  | 10d | 2013-01-14 | 2013-01-25 | 86d |
| 83 | 6.7.1 | Write Technical Specification |  | 10d | 2013-01-14 | 2013-01-25 | 86d |
| 84 | 6.8 | **Development** |  | 11d | 2013-01-14 | 2013-01-28 | 85d |
| 85 | 6.8.1 | **OREG** |  | 11d | 2013-01-14 | 2013-01-28 | 85d |
| 86 | 6.8.1.1 | Rules Engine/OREG Decoupling and integration testing |  | 5d | 2013-01-14 | 2013-01-18 | 91d |
| 87 | 6.8.1.2 | Common Changes (Desktop and Mobile) |  | 11d | 2013-01-14 | 2013-01-28 | 85d |
| 88 | 6.8.1.3 | Desktop Only Changes |  | 1d | 2013-01-14 | 2013-01-14 | 95d |
| 89 | 6.8.1.4 | Enter rules and data into database |  | 1d | 2013-01-14 | 2013-01-14 | 95d |
| 90 | 6.8.1.5 | Unit Test (Phase 2 to test code against UI) |  | 11d | 2013-01-14 | 2013-01-28 | 85d |
| 91 | 6.8.1.6 | Code review |  | 0.5d | 2013-01-14 | 2013-01-14 | 95.5d |
| 92 | 6.8.1.7 | OREG development complete | milestone | 0d | 2013-01-14 | 2013-01-14 | 96d |
| 93 | 6.8.2 | **Jira Tickets** |  | 11d | 2013-01-14 | 2013-01-28 | 85d |
| 94 | 6.8.2.1 | **Bundle 1** |  | 11d | 2013-01-14 | 2013-01-28 | 85d |
| 95 | 6.8.2.1.1 | 1050-Prod: Students with enroll status = FS can access oreg/fixing summary report so fss students won't be counted. |  | 3d | 2013-01-14 | 2013-01-16 | 93d |
| 96 | 6.8.2.1.2 | 1047-Prod: Term address in OREG not in sycnh with websis |  | 5d | 2013-01-14 | 2013-01-18 | 91d |
| 97 | 6.8.2.1.3 | 1055-Old phone number appearing on addressess |  | 11d | 2013-01-14 | 2013-01-28 | 85d |
| 98 | 6.8.2.2 | **Bundle 2** |  | 6d | 2013-01-14 | 2013-01-21 | 90d |
| 99 | 6.8.2.2.1 | 1036-Advisor landing page: status column sort error |  | 6d | 2013-01-14 | 2013-01-21 | 90d |
| 100 | 6.8.2.2.2 | 1042-Change approval process for mobile approvals |  | 2d | 2013-01-14 | 2013-01-15 | 94d |
| 101 | 6.8.2.2.3 | 1046-Prod: Freshman Folder link not working for admins |  | 2d | 2013-01-14 | 2013-01-15 | 94d |
| 102 | 6.8.2.2.4 | 1052-GASP status adjustment |  | 2d | 2013-01-14 | 2013-01-15 | 94d |
| 103 | 6.8.2.2.5 | 1054-Auto save when subject is added |  | 1d | 2013-01-14 | 2013-01-14 | 95d |
| 104 | 6.8.2.2.6 | 1053-Adjust messaging for 18.01A and 18.02A (includes mobile) |  | 2d | 2013-01-14 | 2013-01-15 | 94d |
| 105 | 6.8.2.2.7 | 1056--Report Summary By Date CSV and PDF Downloads Incorrect |  | 1d | 2013-01-14 | 2013-01-14 | 95d |
| 106 | 6.8.2.3 | Jira development complete | milestone | 0d | 2013-01-14 | 2013-01-14 | 96d |
| 107 | 6.8.3 | Development of new requirements for spring messaging |  | 9d | 2013-01-14 | 2013-01-24 | 87d |

| ID | WBS | Task | Type | Duration | Start | Finish | Total slack |
| --- | --- | --- | --- | --- | --- | --- | --- |
| 108 | 6.9 | **Test Preparation** |  | 25d? | 2013-01-14 | 2013-02-15 | 71d |
| 109 | 6.9.1 | Identify data needs - 1st draft |  | 5d | 2013-01-14 | 2013-01-18 | 91d |
| 110 | 6.9.2 | Build test suite in QC |  | 2d | 2013-01-14 | 2013-02-01 | 81.6d |
| 111 | 6.9.3 | Write test cases |  | 15d | 2013-01-14 | 2013-02-01 | 81d |
| 112 | 6.9.4 | Review test cases with team |  | 1d? | 2013-01-14 | 2013-01-14 | 95d |
| 113 | 6.9.5 | Update test cases based on feedback |  | 25d | 2013-01-14 | 2013-02-15 | 71d |
| 114 | 6.9.6 | Identify data needs - final draft |  | 25d | 2013-01-14 | 2013-02-15 | 71d |
| 115 | 6.9.7 | PRDE is rolled to fall (spring population available) |  | 1d | 2013-01-14 | 2013-01-14 | 95d |
| 116 | 6.9.8 | Refresh TEST database |  | 1d | 2013-01-14 | 2013-01-14 | 95d |
| 117 | 6.9.9 | Do data mining |  | 13d | 2013-01-14 | 2013-01-30 | 83d |
| 118 | 6.9.10 | Test preparation complete | milestone | 0d | 2013-01-14 | 2013-01-14 | 96d |
| 119 | 6.9.11 | Write test cases for new requirements for spring messaging (includes data requirements analysis) |  | 5d | 2013-01-14 | 2013-01-18 | 91d |
| 120 | 6.10 | **Systems Integration Test** |  | 15d | 2013-01-14 | 2013-02-01 | 81d |
| 121 | 6.10.1 | **OREG** |  | 15d | 2013-01-14 | 2013-02-01 | 81d |
| 122 | 6.10.1.1 | Execute test cases |  | 15d | 2013-01-14 | 2013-02-01 | 81d |
| 123 | 6.10.1.2 | Bugfixing |  | 9d | 2013-01-14 | 2013-01-24 | 87d |
| 124 | 6.10.2 | **Jira tickets** |  | 12d | 2013-01-14 | 2013-01-29 | 84d |
| 125 | 6.10.2.1 | **Bundle 1** |  | 12d | 2013-01-14 | 2013-01-29 | 84d |
| 126 | 6.10.2.1.1 | Execute test cases |  | 12d | 2013-01-14 | 2013-01-29 | 84d |
| 127 | 6.10.2.1.2 | Bugfixing |  | 11d | 2013-01-14 | 2013-01-28 | 85d |
| 128 | 6.10.2.2 | **Bundle 2** |  | 11d | 2013-01-14 | 2013-01-28 | 85d |
| 129 | 6.10.2.2.1 | Execute test cases |  | 11d | 2013-01-14 | 2013-01-28 | 85d |
| 130 | 6.10.2.2.2 | Bugfixing |  | 11d | 2013-01-14 | 2013-01-28 | 85d |
| 131 | 6.11 | Regression Testing |  | 15d | 2013-01-14 | 2013-02-01 | 81d |
| 132 | 6.12 | SIT of new requirements for spring messaging |  | 4d | 2013-01-14 | 2013-01-17 | 92d |
| 133 | 6.13 | End to end testing (includes 1052 and RT 2107132 (gasp3 lock script)) |  | 2d | 2013-01-14 | 2013-01-15 | 94d |
| 134 | 6.14 | Load Testing |  | 1d | 2013-01-14 | 2013-01-14 | 95d |
| 135 | 6.15 | User Acceptance Test |  | 1d? | 2013-01-14 | 2013-01-14 | 95d |

| ID | WBS | Task | Type | Duration | Start | Finish | Total slack |
| --- | --- | --- | --- | --- | --- | --- | --- |
| 136 | 6.16 | **Deployment Preparation** |  | 13d? | 2013-01-14 | 2013-01-30 | 83d |
| 137 | 6.16.1 | Create deployment plan |  | 5d | 2013-01-14 | 2013-01-18 | 91d |
| 138 | 6.16.2 | Review deployment plan with participants |  | 1d? | 2013-01-14 | 2013-01-14 | 95d |
| 139 | 6.16.3 | Create registration support plan |  | 13d | 2013-01-14 | 2013-01-30 | 83d |
| 140 | 6.17 | Go-live | milestone | 0d | 2013-01-14 | 2013-01-14 | 96d |
| 141 | 6.18 | Prod smoke test |  | 5d | 2013-01-14 | 2013-01-18 | 91d |
| 142 | 6.19 | Registration opens | milestone | 0d | 2013-01-14 | 2013-01-14 | 96d |
| 143 | 6.20 | Registration support |  | 10d | 2013-01-14 | 2013-01-25 | 86d |
